# DIGRAMA GANTT DE LA OBRA CABO INGA

Schedule from MS Project, 2018-10-01 to 2018-12-29, costs in S.
Microsoft

## Calendars

- Estándar: Mon-Sun 08:00-13:00, 14:00-17:00.

## Schedule

| ID | WBS | Task | Type | Duration | Start | Finish | Predecessors | Total slack | Free slack | Cost | Text1 |
| --- | --- | --- | --- | --- | --- | --- | --- | --- | --- | --- | --- |
| 1 | 1 | **REPARACION DE VIAS DEPARTAMENTALES; EN EL (LA) RUTA DEPARTAMENTAL TU - 109, TRAMO EMP. TU - 108 EL HUASIMO - CABO INGA DISTRITO DE SAN JACINTO, PROVINCIA TUMBES, DEPARTAMENTO TUMBES.** |  | 90d | 2018-10-01 | 2018-12-29 |  | 0d |  | 1,979,432.64 |  |
| 2 | 1.1 | INICIO DEL PROYECTO | milestone | 0d | 2018-10-01 | 2018-10-01 |  | 0d |  |  |  |
| 3 | 1.2 | **REPARACION DE VIAS** |  | 90d | 2018-10-01 | 2018-12-29 |  | 0d |  | 1,979,432.64 | 01 |
| 4 | 1.2.1 | **OBRAS PROVISIONALES** |  | 90d | 2018-10-01 | 2018-12-29 |  | 0d |  | 85,060.99 | 01.01 |
| 5 | 1.2.1.1 | SUMINISTRO Y COLOCACION DE CARTEL DE OBRA (5.60x3.40m) |  | 1d | 2018-10-01 | 2018-10-01 | 2 | 86d | 0d | 1,074.18 | 01.01.01 |
| 6 | 1.2.1.2 | CASETA PARA OFICINA, ALMACEN Y GUARDIANIA |  | 3d | 2018-10-02 | 2018-10-04 | 5 | 86d |  | 3,364 | 01.01.02 |
| 7 | 1.2.1.3 | MOVILIZACION Y DESMOVILIZACION DE EQUIPOS |  | 30d | 2018-10-01 | 2018-10-30 | 2SS | 0d |  | 19,500 | 01.01.03 |
| 8 | 1.2.1.4 | MANTENIMIENTO DEL TRANSITO Y SEGURIDAD VIAL |  | 90d | 2018-10-01 | 2018-12-29 | 7SS | 0d |  | 7,074.18 | 01.01.04 |
| 9 | 1.2.1.5 | PLAN DE MONITOREO DE IMPACTO AMBIENTAL |  | 90d | 2018-10-01 | 2018-12-29 | 8SS | 0d |  | 32,466.83 | 01.01.05 |
| 10 | 1.2.1.6 | PLAN DE MONITOREO ARQUEOLOGICO |  | 30d | 2018-10-01 | 2018-10-30 | 9SS | 0d |  | 8,003.8 | 01.01.06 |
| 11 | 1.2.1.7 | ELABORACION, IMPLEMENTACION Y ADMINISTRACION DEL PLAN DE SEGURIDAD Y SALUD EN EL TRABAJO |  | 90d | 2018-10-01 | 2018-12-29 | 10SS | 0d |  | 13,578 | 01.01.07 |
| 12 | 1.2.2 | **TRABAJOS PRELIMINARES** |  | 60d | 2018-10-03 | 2018-12-01 |  | 0d |  | 78,414 | 01.02 |
| 13 | 1.2.2.1 | TRAZO, NIVELACION Y REPLANTEO |  | 60d | 2018-10-03 | 2018-12-01 | 11SS+2d | 0d |  | 78,414 | 01.02.01 |
| 14 | 1.2.3 | **EXCAVACIONES** |  | 75d | 2018-10-16 | 2018-12-29 |  | 0d |  | 1,815,957.65 | 01.03 |
| 15 | 1.2.3.1 | CORTE DE TERRENO NATURAL CON MAQUINARIA |  | 50d | 2018-10-16 | 2018-12-04 | 13FS-47d | 0d |  | 134,230.16 | 01.03.01 |
| 16 | 1.2.3.2 | PERFILADO Y COMPACTACION DE SUBRASANTE PARA CONFORMACION DE VIA |  | 65d | 2018-10-16 | 2018-12-19 | 15FS-50d | 0d |  | 228,520.8 | 01.03.02 |
| 17 | 1.2.3.3 | BASE GRANULAR MATERIAL SELECCIONADO (AFIRMADO) E=0.20 M |  | 65d | 2018-10-26 | 2018-12-29 | 16SS+10d | 0d |  | 1,054,481.6 | 01.03.03 |
| 18 | 1.2.3.4 | ELIMINACIÓN DE MATERIAL EXCEDENTE D. PROM 25 KM DE LA OBRA (FUERA DEL AREA NATURAL PROTEJIDA) |  | 50d | 2018-10-16 | 2018-12-04 | 15SS | 25d |  | 398,725.09 | 01.03.04 |
| 19 | 1.3 | FIN DEL PROYECTO | milestone | 0d | 2018-12-29 | 2018-12-29 | 17 | 0d |  |  |  |
